# WBS.xml

Schedule from MS Project XML, 2005-10-17 to 2006-04-23, A marks actual dates.
University of Cincinnati

## Calendars

- Standard: Mon-Fri 08:00-12:00, 13:00-17:00; Sat-Sun off. Exceptions (off unless hours are given): 2005-12-03 08:00-12:00, 13:00-17:00, 2006-04-23 08:00-12:00, 13:00-17:00.

## Resources

| Resource |
| --- |
| Design |
| Management |
| Flight controls |
| Propulsion |
| Structure |
| Aerodynamics |
| Whole Group |
| Performance |

## Schedule

| ID | Task | Type | Duration | Start | Finish | Predecessors | Complete | Total slack | Free slack | Constraint | Resources | Work | Actual work |
| --- | --- | --- | --- | --- | --- | --- | --- | --- | --- | --- | --- | --- | --- |
| 1 | Initial Design Layout |  | 1d? | 2005-10-17 A | 2005-10-17 A |  | 100% |  |  | start no earlier than 2005-10-17 | Design | 8h | 8h |
| 2 | Work Break Down structure |  | 1d? | 2005-10-24 A | 2005-10-25 A |  | 100% |  |  | finish no earlier than 2005-10-25 | Management | 8h | 8h |
| 3 | Flight Controls Budget |  | 3d? | 2005-10-24 | 2005-10-27 | 1 |  | 101d | 0d | finish no earlier than 2005-10-27 | Flight controls | 24h |  |
| 4 | Management Budget |  | 3d? | 2005-10-24 | 2005-10-27 | 1 |  | 101d | 0d | finish no earlier than 2005-10-27 | Management | 24h |  |
| 5 | Propulsion Budget |  | 3d? | 2005-10-24 | 2005-10-27 | 1 |  | 101d | 0d | finish no earlier than 2005-10-27 | Propulsion | 24h |  |
| 6 | Structure Budget |  | 3d? | 2005-10-24 | 2005-10-27 | 1 |  | 101d | 0d | finish no earlier than 2005-10-27 | Structure | 24h |  |
| 7 | Wing airfoil selection |  | 5d? | 2005-10-24 | 2005-10-31 |  |  | 120d | 16d | finish no earlier than 2005-10-31 | Aerodynamics | 40h |  |
| 8 | Predicted weights |  | 5d? | 2005-10-24 | 2005-10-31 | 1 |  | 44d | 0d | finish no earlier than 2005-10-31 | Structure | 40h |  |
| 9 | Design loads |  | 5d? | 2005-10-24 | 2005-10-31 | 1 |  | 44d | 0d | finish no earlier than 2005-10-31 | Structure | 40h |  |
| 10 | SAE registration |  | 5d | 2005-10-24 | 2005-10-31 |  |  | 93d | 0d | finish no earlier than 2005-10-31 | Whole Group | 40h |  |
| 11 | Budget for funding board |  | 6d? | 2005-10-27 | 2005-11-03 | 3, 4, 5, 6 |  | 29d | 0d | finish no earlier than 2005-11-03 | Management | 48h |  |
| 12 | Initial performance studies |  | 10d? | 2005-10-24 | 2005-11-07 | 1 |  | 102d | 58d | finish no earlier than 2005-11-07 | Performance | 80h |  |
| 13 | Propeller selection |  | 11d? | 2005-10-24 | 2005-11-07 |  |  | 84d | 10d | finish no earlier than 2005-11-07 | Propulsion | 88h |  |
| 14 | Initial Structural layout/configuration |  | 6d? | 2005-10-31 | 2005-11-07 | 1, 8, 9 |  | 34d | 0d | finish no earlier than 2005-11-07 | Structure | 48h |  |
| 15 | Start purchasing materials |  | 2d? | 2005-11-04 | 2005-11-07 | 11 |  | 29d | 0d | finish no earlier than 2005-11-07 | Management | 16h |  |
| 16 | Wing planform |  | 11d? | 2005-10-31 | 2005-11-14 | 1, 9 |  | 34d | 0d | finish no earlier than 2005-11-14 | Aerodynamics | 88h |  |
| 17 | Landing gear study |  | 5d? | 2005-11-08 | 2005-11-14 | 14 |  | 34d | 0d | finish no earlier than 2005-11-14 | Structure | 40h |  |
| 18 | Belt/Gear configuration |  | 5d? | 2005-11-08 | 2005-11-14 | 13 |  | 44d | 5d | finish no earlier than 2005-10-31 | Propulsion | 40h |  |
| 19 | Intial Control system configuration |  | 5d? | 2005-11-15 | 2005-11-21 | 1, 16, 17 |  | 34d | 0d | finish no earlier than 2005-11-21 | Flight controls | 40h |  |
| 20 | CFD Model |  | 5d? | 2005-11-15 | 2005-11-21 | 1, 7, 16 |  | 111d |  | finish no earlier than 2005-11-21 | Aerodynamics | 40h |  |
| 21 | Plan for building |  | 15d? | 2005-11-08 | 2005-11-28 | 15 |  | 29d | 0d | finish no earlier than 2005-11-28 | Management | 120h |  |
| 22 | Start building plane!!!! |  | 5d? | 2005-11-29 | 2005-12-03 | 15, 21 |  | 29d | 0d | start no earlier than 2005-11-29 | Whole Group | 40h |  |
| 23 | Initial Report Write Up |  | 5d? | 2005-12-05 | 2005-12-09 |  |  | 29d | 0d | finish no earlier than 2005-12-09 | Whole Group | 40h |  |
| 24 | Registration | milestone | 32d? | 2005-10-31 | 2005-12-12 | 10 |  | 93d |  | finish no earlier than 2005-12-12 | Management | 256h |  |
| 25 | Detailed design |  | 56d? | 2005-10-25 | 2006-01-10 | 1 |  | 75d |  | finish no earlier than 2006-01-10 | Design | 448h |  |
| 26 | Detailed Structural layout/configuration |  | 47d? | 2005-11-22 | 2006-01-24 | 14, 16, 17, 19 |  | 42d | 0d | start no earlier than 2005-11-08 | Structure | 376h |  |
| 27 | Detailed Control system configuration |  | 37d? | 2005-11-22 | 2006-01-10 | 19 |  | 52d | 0d | start no earlier than 2005-11-22 | Flight controls | 296h |  |
| 28 | Detailed Propulsion configuration |  | 37d? | 2005-11-22 | 2006-01-10 | 13, 18 |  | 52d | 0d | start no earlier than 2005-11-22 | Propulsion | 296h |  |
| 29 | Detailed performance studies |  | 20d? | 2006-01-25 | 2006-02-21 | 12, 26, 27, 28 |  | 42d |  | finish no earlier than 2006-02-07 | Performance | 160h |  |
| 30 | Report Deadline (postmarked) | milestone | 65d? | 2005-12-12 | 2006-03-10 | 23 |  | 29d |  | finish no earlier than 2006-03-10 | Management | 520h |  |
| 31 | Competition Date | milestone | 2d? | 2006-04-21 | 2006-04-23 |  |  | 0d |  | start no earlier than 2006-04-21 | Whole Group | 16h |  |
